# Atacama Sub-mm Telescope Robotic Observatory

Schedule from Planner, 2010-02-01 to 2014-01-14.
$Id: astro_chile.planner 71 2009-08-08 06:03:39Z cmartin $

## Calendars

- Default: Mon-Fri 08:00-12:00, 13:00-17:00; Sat-Sun off.

## Resources

| Resource |
| --- |
| Glenn |
| Chris Martin |
| Chris Walker |
| Craig Kulesa |
| Chris Groppi |
| Patricio Mena |
| Greg Wright |
| Gary Kader |
| Tony Stark |

## Schedule

| ID | Task | Type | Duration | Start | Finish | Predecessors | Work |
| --- | --- | --- | --- | --- | --- | --- | --- |
| 1 | Design Phase |  |  | 2010-02-01 | 2010-10-08 |  | 1440h |
| 2 | Design Review | milestone | 0d | 2010-10-08 | 2010-10-08 | 1 |  |
| 3 | Telescope Preparation |  |  | 2010-10-11 | 2012-07-13 | 2 | 3680h |
| 4 | Telescope Pre-Shipment Review | milestone | 0d | 2012-07-13 | 2012-07-13 | 3 |  |
| 5 | 350 GHz SuperCAM Preparation |  |  | 2010-10-11 | 2011-12-02 | 2 | 2400h |
| 6 | 350 GHz SuperCAM Pre-Shipment Review | milestone | 0d | 2011-12-02 | 2011-12-02 | 5 |  |
| 7 | Telescope Installation on plateau |  |  | 2012-09-12 | 2012-12-04 | 6, 4FS+1440h | 480h |
| 8 | 350 GHz First Light | milestone | 0d | 2012-12-04 | 2012-12-04 | 7 |  |
| 9 | 350 GHz Commissioning Survey |  |  | 2012-12-05 | 2013-10-22 | 8 | 1840h |
| 10 | 650/690 GHz SuperCAM Preparation |  |  | 2010-10-11 | 2013-08-23 | 2 | 6000h |
| 11 | 650/690 GHz SuperCAM Pre-Shipment Review | milestone | 0d | 2013-08-23 | 2013-08-23 | 10 |  |
| 12 | 650/690 GHz Installation |  |  | 2013-10-23 | 2014-01-14 | 11FS+1440h | 480h |
| 13 | 650/690 GHz First Light | milestone | 0d | 2014-01-14 | 2014-01-14 | 12 |  |
